# Schulungsprojekt

How a schedule from MS Project changed from version to version. A marks actual dates.

## Version 1 (saved 2024-11-13, file 16893707907100)

| ID | WBS | Task | Duration | Start | Finish | Predecessors | Total float |
| --- | --- | --- | --- | --- | --- | --- | --- |
| 1 | 1 | **NEW WORK OFFICES** | 335d | 2024-05-13 | 2025-08-22 |  | 0d |
| 2 | 1.1 | **Baugrube** | 20d | 2024-05-13 | 2024-06-07 |  | 0d |
| 3 |  | Baubeginn | 0d | 2024-05-13 | 2024-05-13 |  | 335d |
| 4 |  | Baugrube | 20d | 2024-05-13 | 2024-06-07 |  | 0d |
| 5 | 1.2 | **Rohbau** | 60d | 2024-06-10 | 2024-08-30 |  | 0d |
| 6 |  | Start Rohbau | 0d | 2024-06-10 | 2024-06-10 | 7SS | 315d |
| 7 |  | Bodenplatte | 15d | 2024-06-10 | 2024-06-28 | 4 | 0d |
| 8 |  | Untergeschoss | 10d | 2024-07-01 | 2024-07-12 | 7 | 0d |
| 9 |  | Erdgeschoss | 10d | 2024-07-15 | 2024-07-26 | 8 | 0d |
| 10 |  | Obergeschoss | 10d | 2024-07-29 | 2024-08-09 | 9 | 0d |
| 11 |  | Dach | 15d | 2024-08-12 | 2024-08-30 | 10 | 0d |
| 12 |  | Rohbau fertig | 0d | 2024-08-30 | 2024-08-30 | 11 | 0d |
| 13 | 1.3 | **Fassade** | 25d | 2024-09-16 | 2024-10-18 |  | 0d |
| 14 |  | Fenster | 10d | 2024-09-16 | 2024-09-27 | 12FS+10d | 0d |
| 15 |  | Fassade dicht | 0d | 2024-09-27 | 2024-09-27 | 14 | 220d |
| 16 |  | WDVS | 10d | 2024-09-30 | 2024-10-11 | 15 | 220d |
| 17 |  | Außenputz | 5d | 2024-10-14 | 2024-10-18 | 16 | 220d |
| 18 | 1.4 | **Ausbau** | 200d | 2024-10-04 | 2025-07-11 |  | 0d |
| 19 | 1.4.1 | **Büro 1. OG** | 100d | 2024-10-04 | 2025-02-21 |  | 0d |
| 20 |  | Start Ausbau | 0d | 2024-10-04 | 2024-10-04 | 14FS+5d | 0d |
| 21 |  | Innenputz | 5d | 2024-10-07 | 2024-10-11 | 20 | 0d |
| 22 |  | Rohrleitungen HLS | 10d | 2024-10-14 | 2024-10-25 | 21 | 30d |
| 23 |  | Leitungen Boden | 5d | 2024-10-21 | 2024-10-25 | 22SS+5d | 30d |
| 24 |  | Hohlboden | 5d | 2024-10-28 | 2024-11-01 | 22, 23 | 30d |
| 25 |  | Estrich | 2d | 2024-11-04 | 2024-11-05 | 24 | 30d |
| 26 |  | Estrich Trocknung | 8d | 2024-11-06 | 2024-11-15 | 25 | 30d |
| 27 |  | Eckwand + 1. Seite | 5d | 2024-11-18 | 2024-11-22 | 26 | 30d |
| 28 |  | Leitung Wand | 5d | 2024-11-25 | 2024-11-29 | 27 | 30d |
| 29 |  | 2. Seite + Q3 | 5d | 2024-12-02 | 2024-12-06 | 28 | 30d |
| 30 |  | 1. Anstrich | 5d | 2024-12-09 | 2024-12-13 | 29 | 30d |
| 31 |  | Systemtrennwände | 10d | 2024-12-16 | 2024-12-27 | 30 | 30d |
| 32 |  | Bodenbelag | 5d | 2024-12-30 | 2025-01-03 | 31 | 30d |
| 33 |  | Bodentanks | 5d | 2025-01-06 | 2025-01-10 | 32 | 30d |
| 34 |  | Türen | 5d | 2025-01-06 | 2025-01-10 | 33SS | 30d |
| 35 |  | Heizkörper | 5d | 2025-01-13 | 2025-01-17 | 34, 33 | 30d |
| 36 |  | Feininstallation HLS | 10d | 2025-01-13 | 2025-01-24 | 35SS | 30d |
| 37 |  | Schließzylinder | 1d | 2025-01-27 | 2025-01-27 | 36 | 30d |
| 38 |  | Schalter + Lampen | 5d | 2025-01-27 | 2025-01-31 | 37SS | 30d |
| 39 |  | 2. Anstrich | 5d | 2025-02-03 | 2025-02-07 | 38 | 30d |
| 40 |  | WC-Gegenstände | 5d | 2025-02-10 | 2025-02-14 | 39, 37 | 30d |
| 41 |  | Endreinigung | 5d | 2025-02-17 | 2025-02-21 | 40 | 30d |
| 42 | 1.4.2 | **Büro 2. OG** | 105d | 2024-10-21 | 2025-03-14 |  | 0d |
| 43 |  | Innenputz | 5d | 2024-10-21 | 2024-10-25 | 21FS+5d | 0d |
| 44 |  | Rohrleitungen HLS | 10d | 2024-10-28 | 2024-11-08 | 43 | 15d |
| 45 |  | Leitungen Boden | 5d | 2024-11-04 | 2024-11-08 | 44SS+5d | 15d |
| 46 |  | Hohlboden | 5d | 2024-11-11 | 2024-11-15 | 44, 45 | 15d |
| 47 |  | Estrich | 2d | 2024-11-18 | 2024-11-19 | 46 | 15d |
| 48 |  | Estrich Trocknung | 8d | 2024-11-20 | 2024-11-29 | 47 | 15d |
| 49 |  | Eckwand + 1. Seite | 5d | 2024-12-09 | 2024-12-13 | 48FS+5d | 15d |
| 50 |  | Leitung Wand | 5d | 2024-12-16 | 2024-12-20 | 49 | 15d |
| 51 |  | 2. Seite + Q3 | 5d | 2024-12-23 | 2024-12-27 | 50 | 15d |
| 52 |  | 1. Anstrich | 5d | 2024-12-30 | 2025-01-03 | 51 | 15d |
| 53 |  | Systemtrennwände | 10d | 2025-01-06 | 2025-01-17 | 52 | 15d |
| 54 |  | Bodenbelag | 5d | 2025-01-20 | 2025-01-24 | 53 | 15d |
| 55 |  | Bodentanks | 5d | 2025-01-27 | 2025-01-31 | 54 | 15d |
| 56 |  | Türen | 5d | 2025-01-27 | 2025-01-31 | 55SS | 15d |
| 57 |  | Heizkörper | 5d | 2025-02-03 | 2025-02-07 | 56, 55 | 15d |
| 58 |  | Feininstallation HLS | 10d | 2025-02-03 | 2025-02-14 | 57SS | 15d |
| 59 |  | Schließzylinder | 1d | 2025-02-17 | 2025-02-17 | 58 | 15d |
| 60 |  | Schalter + Lampen | 5d | 2025-02-17 | 2025-02-21 | 59SS | 15d |
| 61 |  | 2. Anstrich | 5d | 2025-02-24 | 2025-02-28 | 60 | 15d |
| 62 |  | WC-Gegenstände | 5d | 2025-03-03 | 2025-03-07 | 61, 59 | 15d |
| 63 |  | Endreinigung | 5d | 2025-03-10 | 2025-03-14 | 62 | 15d |
| 64 | 1.4.3 | **Büro 3. OG** | 110d | 2024-11-04 | 2025-04-04 |  | 0d |
| 65 |  | Innenputz | 5d | 2024-11-04 | 2024-11-08 | 43FS+5d | 0d |
| 66 |  | Rohrleitungen HLS | 10d | 2024-11-11 | 2024-11-22 | 65 | 0d |
| 67 |  | Leitungen Boden | 5d | 2024-11-18 | 2024-11-22 | 66SS+5d | 0d |
| 68 |  | Hohlboden | 5d | 2024-11-25 | 2024-11-29 | 66, 67 | 0d |
| 69 |  | Estrich | 2d | 2024-12-02 | 2024-12-03 | 68 | 0d |
| 70 |  | Estrich Trocknung | 8d | 2024-12-04 | 2024-12-13 | 69 | 0d |

| ID | WBS | Task | Duration | Start | Finish | Predecessors | Total float |
| --- | --- | --- | --- | --- | --- | --- | --- |
| 71 |  | Eckwand + 1. Seite | 5d | 2024-12-30 | 2025-01-03 | 70FS+10d | 0d |
| 72 |  | Leitung Wand | 5d | 2025-01-06 | 2025-01-10 | 71 | 0d |
| 73 |  | 2. Seite + Q3 | 5d | 2025-01-13 | 2025-01-17 | 72 | 0d |
| 74 |  | 1. Anstrich | 5d | 2025-01-20 | 2025-01-24 | 73 | 0d |
| 75 |  | Systemtrennwände | 10d | 2025-01-27 | 2025-02-07 | 74 | 0d |
| 76 |  | Bodenbelag | 5d | 2025-02-10 | 2025-02-14 | 75 | 0d |
| 77 |  | Bodentanks | 5d | 2025-02-17 | 2025-02-21 | 76 | 0d |
| 78 |  | Türen | 5d | 2025-02-17 | 2025-02-21 | 77SS | 0d |
| 79 |  | Heizkörper | 5d | 2025-02-24 | 2025-02-28 | 78, 77 | 0d |
| 80 |  | Feininstallation HLS | 10d | 2025-02-24 | 2025-03-07 | 79SS | 0d |
| 81 |  | Schließzylinder | 1d | 2025-03-10 | 2025-03-10 | 80 | 0d |
| 82 |  | Schalter + Lampen | 5d | 2025-03-10 | 2025-03-14 | 81SS | 0d |
| 83 |  | 2. Anstrich | 5d | 2025-03-17 | 2025-03-21 | 82 | 0d |
| 84 |  | WC-Gegenstände | 5d | 2025-03-24 | 2025-03-28 | 83, 81 | 0d |
| 85 |  | Endreinigung | 5d | 2025-03-31 | 2025-04-04 | 84 | 0d |
| 86 |  | Ausbau fertig | 0d | 2025-04-04 | 2025-04-04 | 85, 41, 63 | 0d |
| 87 | 1.4.4 | **Mängelbeseitigung** | 35d | 2025-05-26 | 2025-07-11 |  | 0d |
| 88 |  | Mängelaufnahme | 5d | 2025-05-26 | 2025-05-30 | 94FS+5d | 0d |
| 89 |  | Dokumentation | 5d | 2025-06-02 | 2025-06-06 | 88 | 0d |
| 90 |  | Mängelabarbeitung | 20d | 2025-06-09 | 2025-07-04 | 89 | 0d |
| 91 |  | Nachkontrolle | 5d | 2025-07-07 | 2025-07-11 | 90 | 0d |
| 92 |  | Mängelfrei | 0d | 2025-07-11 | 2025-07-11 | 91 | 0d |
| 93 | 1.5 | **Inbetriebnahme** | 90d | 2025-04-21 | 2025-08-22 |  | 0d |
| 94 |  | Inbetriebnahme TGA | 20d | 2025-04-21 | 2025-05-16 | 86FS+10d, 85 | 0d |
| 95 |  | Übergabe an Bauherr | 0d | 2025-07-18 | 2025-07-18 | 92FS+5d | 0d |
| 96 |  | Einzug Kunde | 10d | 2025-08-11 | 2025-08-22 | 95FS+15d | 0d |

## Version 2 (saved 2026-01-16, file 24870382108828)

Last finish 2025-08-22 → 2026-07-20 (+332d). Complete tasks 0 → 53.

Added:

| ID | Task | Duration | Start | Finish | Resources |
| --- | --- | --- | --- | --- | --- |
| 42 | Außenanlagen VP2 | 0d | 2025-12-08 A | 2025-12-08 A | Außenanlagen |
| 88 | **Kindergarten EG** | 1d | 2025-11-03 A | 2025-11-03 |  |
| 89 | Innenputz | 5d | 2025-11-03 A | 2025-11-07 A | Innenputz |
| 90 | Rohrleitungen HLS | 10d | 2025-11-10 A | 2025-11-21 A | HLS |
| 91 | Estrich | 2d | 2025-11-24 A | 2025-11-25 A | Estrich |
| 92 | Estrich Trocknung | 8d | 2025-11-26 A | 2025-12-05 A | Estrich |
| 93 | 1. Seite | 5d | 2025-12-22 A | 2025-12-26 A | Trockenbau |
| 94 | Leitung Wand | 5d | 2025-12-29 A | 2026-01-02 A | Elektro - Fa. Elektro Blitz |
| 95 | 2. Seite + Q3 | 5d | 2026-01-05 A | 2026-01-09 | Trockenbau |
| 96 | 1. Anstrich | 5d | 2026-01-12 A | 2026-01-16 | Maler |
| 97 | Fliesen | 5d | 2026-01-19 | 2026-01-23 | Boden |
| 98 | Küchenbauer | 10d | 2026-01-26 | 2026-02-06 | Küchenbauer |
| 99 | Bodenbelag | 5d | 2026-02-09 | 2026-02-13 | Teppich |
| 100 | Türen | 5d | 2026-02-09 | 2026-02-13 | Türen |
| 101 | Heizkörper | 5d | 2026-02-16 | 2026-02-20 | Heizungsbauer |
| 102 | Feininstallation HLS | 5d | 2026-02-16 | 2026-02-20 | HLS |
| 103 | Schließzylinder | 1d | 2026-02-23 | 2026-02-23 | Bauherr |
| 104 | Schalter + Lampen | 5d | 2026-02-23 | 2026-02-27 | Elektro - Fa. Elektro Blitz |
| 105 | 2. Anstrich | 5d | 2026-03-02 | 2026-03-06 | Maler |
| 106 | WC-Gegenstände | 5d | 2026-03-09 | 2026-03-13 | Sanitär - Fa. Rohr Frei |
| 107 | Endreinigung | 5d | 2026-03-16 | 2026-03-20 | Reinigung - Fa. Gebäudereinigung Blitzblank |
| 108 | Übergabe | 0d | 2026-03-23 | 2026-03-23 | Meilensteine |
| 118 | **Gebäude 2** | 1d | 2025-04-28 | 2025-04-28 |  |
| 119 | Ausbau | 1d | 2025-04-28 | 2025-04-28 |  |

Removed: 96 Einzug Kunde

Changed:

| ID | Task | Start | Finish | Duration | Complete | Total float | Predecessors | Other |
| --- | --- | --- | --- | --- | --- | --- | --- | --- |
| 1 | **Gebäude 1** | 2024-05-13 → 2025-04-28 A (+350d) | 2025-08-22 → 2025-04-28 (-116d) | 335d → 1d | 0% → 57% | 0d → none |  | was named NEW WORK OFFICES; baseline start none → 2024-05-20; baseline finish none → 2025-07-28 |
| 2 | **Baugrube** | 2024-05-13 → 2025-04-28 A (+350d) | 2024-06-07 → 2025-04-28 (+325d) | 20d → 1d | 0% → 100% | 0d → none |  | baseline start none → 2024-05-20; baseline finish none → 2024-06-14 |
| 3 | Baugrube | 2024-05-13 → 2025-05-12 A (+364d) | 2024-06-07 → 2025-06-06 A (+364d) |  | 0% → 100% | 0d → none |  | baseline start none → 2024-05-20; baseline finish none → 2024-06-14 |
| 4 | Baubeginn | 2024-05-13 → 2025-04-28 A (+350d) | 2024-05-13 → 2025-04-28 A (+350d) |  | 0% → 100% | 335d → none |  | baseline start none → 2024-05-20; baseline finish none → 2024-05-20 |
| 5 | **Rohbau** | 2024-06-10 → 2025-06-09 A (+364d) | 2024-08-30 → 2025-06-09 (+283d) | 60d → 1d | 0% → 100% | 0d → none |  | baseline start none → 2024-06-17; baseline finish none → 2024-09-09 |
| 6 | Bodenplatte | 2024-06-10 → 2025-06-09 A (+364d) | 2024-06-28 → 2025-06-27 A (+364d) |  | 0% → 100% | 0d → none |  | baseline start none → 2024-06-17; baseline finish none → 2024-07-05 |
| 7 | Untergeschoss | 2024-07-01 → 2025-06-30 A (+364d) | 2024-07-12 → 2025-07-11 A (+364d) |  | 0% → 100% | 0d → none |  | baseline start none → 2024-07-08; baseline finish none → 2024-07-19 |
| 8 | Erdgeschoss | 2024-07-15 → 2025-07-14 A (+364d) | 2024-07-26 → 2025-07-25 A (+364d) |  | 0% → 100% | 0d → none |  | baseline start none → 2024-07-22; baseline finish none → 2024-08-02 |
| 9 | Obergeschoss | 2024-07-29 → 2025-07-28 A (+364d) | 2024-08-09 → 2025-08-08 A (+364d) |  | 0% → 100% | 0d → none |  | baseline start none → 2024-08-05; baseline finish none → 2024-08-16 |
| 10 | Dach | 2024-08-12 → 2025-08-11 A (+364d) | 2024-08-30 → 2025-08-29 A (+364d) |  | 0% → 100% | 0d → none |  | resources Zimmerer → none; baseline start none → 2024-08-19; baseline finish none → 2024-09-06 |
| 11 | Rohbau fertig | 2024-08-30 → 2025-09-01 A (+367d) | 2024-08-30 → 2025-09-01 A (+367d) |  | 0% → 100% | 0d → none |  | baseline start none → 2024-09-09; baseline finish none → 2024-09-09 |
| 12 | Start Rohbau | 2024-06-10 → 2025-06-09 A (+364d) | 2024-06-10 → 2025-06-09 A (+364d) |  | 0% → 100% | 315d → none |  | baseline start none → 2024-06-17; baseline finish none → 2024-06-17 |
| 13 | **Fassade** | 2024-09-16 → 2025-09-15 A (+364d) | 2024-10-18 → 2025-09-15 (+332d) | 25d → 1d | 0% → 100% | 0d → none |  | baseline start none → 2024-09-23; baseline finish none → 2024-10-25 |
| 14 | Fenster | 2024-09-16 → 2025-09-15 A (+364d) | 2024-09-27 → 2025-09-26 A (+364d) |  | 0% → 100% | 0d → none |  | baseline start none → 2024-09-23; baseline finish none → 2024-10-04 |
| 15 | Fassade dicht | 2024-09-27 → 2025-09-29 A (+367d) | 2024-09-27 → 2025-09-29 A (+367d) |  | 0% → 100% | 220d → none |  | baseline start none → 2024-10-07; baseline finish none → 2024-10-07 |
| 16 | WDVS | 2024-09-30 → 2025-09-29 A (+364d) | 2024-10-11 → 2025-10-10 A (+364d) |  | 0% → 100% | 220d → none |  | baseline start none → 2024-10-07; baseline finish none → 2024-10-18 |
| 17 | Außenputz | 2024-10-14 → 2025-10-13 A (+364d) | 2024-10-18 → 2025-10-17 A (+364d) |  | 0% → 100% | 220d → none |  | baseline start none → 2024-10-21; baseline finish none → 2024-10-25 |
| 18 | **Ausbau** | 2024-10-04 → 2025-10-06 A (+367d) | 2025-07-11 → 2025-10-06 (+87d) | 200d → 1d | 0% → 50% | 0d → none |  | baseline start none → 2024-10-14; baseline finish none → 2025-07-21 |
| 19 | **Büro 1. OG** | 2024-10-04 → 2025-10-06 A (+367d) | 2025-02-21 → 2025-10-06 (+227d) | 100d → 1d | 0% → 76% | 0d → none |  | baseline start none → 2024-10-14; baseline finish none → 2025-02-28 |
| 20 | Start Ausbau | 2024-10-04 → 2025-10-06 A (+367d) | 2024-10-04 → 2025-10-06 A (+367d) |  | 0% → 100% | 0d → none |  | baseline start none → 2024-10-14; baseline finish none → 2024-10-14 |
| 21 | Innenputz | 2024-10-07 → 2025-10-06 A (+364d) | 2024-10-11 → 2025-10-10 A (+364d) |  | 0% → 100% | 0d → none |  | baseline start none → 2024-10-14; baseline finish none → 2024-10-18 |
| 22 | Rohrleitungen HLS | 2024-10-14 → 2025-10-13 A (+364d) | 2024-10-25 → 2025-10-24 A (+364d) |  | 0% → 100% | 30d → none |  | baseline start none → 2024-10-21; baseline finish none → 2024-11-01 |
| 23 | Leitungen Boden | 2024-10-21 → 2025-10-20 A (+364d) | 2024-10-25 → 2025-10-24 A (+364d) |  | 0% → 100% | 30d → none |  | resources Elektro → Elektro - Fa. Elektro Blitz; baseline start none → 2024-10-28; baseline finish none → 2024-11-01 |
| 24 | Hohlboden | 2024-10-28 → 2025-10-27 A (+364d) | 2024-11-01 → 2025-10-31 A (+364d) |  | 0% → 100% | 30d → none |  | baseline start none → 2024-11-04; baseline finish none → 2024-11-08 |
| 25 | Estrich | 2024-11-04 → 2025-11-03 A (+364d) | 2024-11-05 → 2025-11-04 A (+364d) |  | 0% → 100% | 30d → none |  | baseline start none → 2024-11-11; baseline finish none → 2024-11-12 |
| 26 | Estrich Trocknung | 2024-11-06 → 2025-11-05 A (+364d) | 2024-11-15 → 2025-11-14 A (+364d) |  | 0% → 100% | 30d → none |  | baseline start none → 2024-11-13; baseline finish none → 2024-11-22 |
| 27 | Eckwand + 1. Seite | 2024-11-18 → 2025-11-17 A (+364d) | 2024-11-22 → 2025-11-21 A (+364d) |  | 0% → 100% | 30d → none |  | baseline start none → 2024-11-25; baseline finish none → 2024-11-29 |
| 28 | Leitung Wand | 2024-11-25 → 2025-11-24 A (+364d) | 2024-11-29 → 2025-11-28 A (+364d) |  | 0% → 100% | 30d → none |  | resources Elektro → Elektro - Fa. Elektro Blitz; baseline start none → 2024-12-02; baseline finish none → 2024-12-06 |
| 29 | 2. Seite + Q3 | 2024-12-02 → 2025-12-01 A (+364d) | 2024-12-06 → 2025-12-05 A (+364d) |  | 0% → 100% | 30d → none |  | baseline start none → 2024-12-09; baseline finish none → 2024-12-13 |
| 30 | 1. Anstrich | 2024-12-09 → 2025-12-08 A (+364d) | 2024-12-13 → 2025-12-12 A (+364d) |  | 0% → 100% | 30d → none |  | baseline start none → 2024-12-16; baseline finish none → 2024-12-20 |
| 31 | Systemtrennwände | 2024-12-16 → 2025-12-15 A (+364d) | 2024-12-27 → 2025-12-26 A (+364d) |  | 0% → 100% | 30d → none |  | baseline start none → 2024-12-23; baseline finish none → 2025-01-03 |
| 32 | Bodenbelag | 2024-12-30 → 2025-12-29 A (+364d) | 2025-01-03 → 2026-01-02 A (+364d) |  | 0% → 100% | 30d → none |  | baseline start none → 2025-01-06; baseline finish none → 2025-01-10 |
| 33 | Bodentanks | 2025-01-06 → 2026-01-05 A (+364d) | 2025-01-10 → 2026-01-09 A (+364d) |  | 0% → 100% | 30d → none |  | baseline start none → 2025-01-13; baseline finish none → 2025-01-17 |
| 34 | Türen | 2025-01-06 → 2026-01-05 A (+364d) | 2025-01-10 → 2026-01-09 A (+364d) |  | 0% → 100% | 30d → none |  | baseline start none → 2025-01-13; baseline finish none → 2025-01-17 |
| 35 | Heizkörper | 2025-01-13 → 2026-01-12 A (+364d) | 2025-01-17 → 2026-01-16 (+364d) |  | 0% → 80% | 30d → none |  | baseline start none → 2025-01-20; baseline finish none → 2025-01-24 |
| 36 | Feininstallation HLS | 2025-01-13 → 2026-01-12 A (+364d) | 2025-01-24 → 2026-01-23 (+364d) |  | 0% → 40% | 30d → none |  | baseline start none → 2025-01-20; baseline finish none → 2025-01-31 |
| 37 | Schließzylinder | 2025-01-27 → 2026-01-26 (+364d) | 2025-01-27 → 2026-01-26 (+364d) |  |  | 30d → none |  | baseline start none → 2025-02-03; baseline finish none → 2025-02-03 |
| 38 | Schalter + Lampen | 2025-01-27 → 2026-01-26 (+364d) | 2025-01-31 → 2026-01-30 (+364d) |  |  | 30d → none |  | resources Elektro → Elektro - Fa. Elektro Blitz; baseline start none → 2025-02-03; baseline finish none → 2025-02-07 |
| 39 | 2. Anstrich | 2025-02-03 → 2026-02-02 (+364d) | 2025-02-07 → 2026-02-06 (+364d) |  |  | 30d → none |  | baseline start none → 2025-02-10; baseline finish none → 2025-02-14 |
| 40 | WC-Gegenstände | 2025-02-10 → 2026-02-09 (+364d) | 2025-02-14 → 2026-02-13 (+364d) |  |  | 30d → none |  | resources Sanitär → Sanitär - Fa. Rohr Frei; baseline start none → 2025-02-17; baseline finish none → 2025-02-21 |
| 41 | Endreinigung | 2025-02-17 → 2026-02-16 (+364d) | 2025-02-21 → 2026-02-20 (+364d) |  |  | 30d → none |  | resources Reinigung → Reinigung - Fa. Gebäudereinigung Blitzblank; baseline start none → 2025-02-24; baseline finish none → 2025-02-28 |
| 43 | **Büro 2. OG** | 2024-10-21 → 2025-10-20 A (+364d) | 2025-03-14 → 2025-10-20 (+220d) | 105d → 1d | 0% → 55% | 0d → none |  | baseline start none → 2024-10-28; baseline finish none → 2025-03-21 |
| 44 | Innenputz | 2024-10-21 → 2025-10-20 A (+364d) | 2024-10-25 → 2025-10-24 A (+364d) |  | 0% → 100% | 0d → none |  | baseline start none → 2024-10-28; baseline finish none → 2024-11-01 |
| 45 | Rohrleitungen HLS | 2024-10-28 → 2025-10-27 A (+364d) | 2024-11-08 → 2025-11-07 A (+364d) |  | 0% → 100% | 15d → none |  | baseline start none → 2024-11-04; baseline finish none → 2024-11-15 |
| 46 | Leitungen Boden | 2024-11-04 → 2025-11-03 A (+364d) | 2024-11-08 → 2025-11-07 A (+364d) |  | 0% → 100% | 15d → none |  | resources Elektro → Elektro - Fa. Elektro Blitz; baseline start none → 2024-11-11; baseline finish none → 2024-11-15 |
| 47 | Hohlboden | 2024-11-11 → 2025-11-10 A (+364d) | 2024-11-15 → 2025-11-14 A (+364d) |  | 0% → 100% | 15d → none |  | baseline start none → 2024-11-18; baseline finish none → 2024-11-22 |
| 48 | Estrich | 2024-11-18 → 2025-11-17 A (+364d) | 2024-11-19 → 2025-11-18 A (+364d) |  | 0% → 100% | 15d → none |  | baseline start none → 2024-11-25; baseline finish none → 2024-11-26 |
| 49 | Estrich Trocknung | 2024-11-20 → 2025-11-19 A (+364d) | 2024-11-29 → 2025-11-28 A (+364d) |  | 0% → 100% | 15d → none |  | baseline start none → 2024-11-27; baseline finish none → 2024-12-06 |
| 50 | Eckwand + 1. Seite | 2024-12-09 → 2025-12-08 A (+364d) | 2024-12-13 → 2025-12-12 A (+364d) |  | 0% → 100% | 15d → none |  | baseline start none → 2024-12-16; baseline finish none → 2024-12-20 |
| 51 | Leitung Wand | 2024-12-16 → 2025-12-15 A (+364d) | 2024-12-20 → 2025-12-19 A (+364d) |  | 0% → 100% | 15d → none |  | resources Elektro → Elektro - Fa. Elektro Blitz; baseline start none → 2024-12-23; baseline finish none → 2024-12-27 |
| 52 | 2. Seite + Q3 | 2024-12-23 → 2025-12-22 A (+364d) | 2024-12-27 → 2025-12-26 A (+364d) |  | 0% → 100% | 15d → none |  | baseline start none → 2024-12-30; baseline finish none → 2025-01-03 |
| 53 | 1. Anstrich | 2024-12-30 → 2025-12-29 A (+364d) | 2025-01-03 → 2026-01-02 A (+364d) |  | 0% → 100% | 15d → none |  | baseline start none → 2025-01-06; baseline finish none → 2025-01-10 |
| 54 | Systemtrennwände | 2025-01-06 → 2026-01-05 A (+364d) | 2025-01-17 → 2026-01-16 (+364d) |  | 0% → 90% | 15d → none |  | baseline start none → 2025-01-13; baseline finish none → 2025-01-24 |
| 55 | Bodenbelag | 2025-01-20 → 2026-01-19 (+364d) | 2025-01-24 → 2026-01-23 (+364d) |  |  | 15d → none |  | baseline start none → 2025-01-27; baseline finish none → 2025-01-31 |
| 56 | Bodentanks | 2025-01-27 → 2026-01-26 (+364d) | 2025-01-31 → 2026-01-30 (+364d) |  |  | 15d → none |  | baseline start none → 2025-02-03; baseline finish none → 2025-02-07 |
| 57 | Türen | 2025-01-27 → 2026-01-26 (+364d) | 2025-01-31 → 2026-01-30 (+364d) |  |  | 15d → none |  | baseline start none → 2025-02-03; baseline finish none → 2025-02-07 |
| 58 | Heizkörper | 2025-02-03 → 2026-02-02 (+364d) | 2025-02-07 → 2026-02-06 (+364d) |  |  | 15d → none |  | baseline start none → 2025-02-10; baseline finish none → 2025-02-14 |
| 59 | Feininstallation HLS | 2025-02-03 → 2026-02-02 (+364d) | 2025-02-14 → 2026-02-13 (+364d) |  |  | 15d → none |  | baseline start none → 2025-02-10; baseline finish none → 2025-02-21 |
| 60 | Schließzylinder | 2025-02-17 → 2026-02-16 (+364d) | 2025-02-17 → 2026-02-16 (+364d) |  |  | 15d → none |  | baseline start none → 2025-02-24; baseline finish none → 2025-02-24 |
| 61 | Schalter + Lampen | 2025-02-17 → 2026-02-16 (+364d) | 2025-02-21 → 2026-02-20 (+364d) |  |  | 15d → none |  | resources Elektro → Elektro - Fa. Elektro Blitz; baseline start none → 2025-02-24; baseline finish none → 2025-02-28 |
| 62 | 2. Anstrich | 2025-02-24 → 2026-02-23 (+364d) | 2025-02-28 → 2026-02-27 (+364d) |  |  | 15d → none |  | baseline start none → 2025-03-03; baseline finish none → 2025-03-07 |
| 63 | WC-Gegenstände | 2025-03-03 → 2026-03-02 (+364d) | 2025-03-07 → 2026-03-06 (+364d) |  |  | 15d → none |  | resources Sanitär → Sanitär - Fa. Rohr Frei; baseline start none → 2025-03-10; baseline finish none → 2025-03-14 |
| 64 | Endreinigung | 2025-03-10 → 2026-03-09 (+364d) | 2025-03-14 → 2026-03-13 (+364d) |  |  | 15d → none |  | resources Reinigung → Reinigung - Fa. Gebäudereinigung Blitzblank; baseline start none → 2025-03-17; baseline finish none → 2025-03-21 |
| 65 | **Büro 3. OG** | 2024-11-04 → 2025-10-27 A (+357d) | 2025-04-04 → 2025-10-27 (+206d) | 110d → 1d | 0% → 42% | 0d → none |  | baseline start none → 2024-11-11; baseline finish none → 2025-04-14 |
| 66 | Innenputz | 2024-11-04 → 2025-10-27 A (+357d) | 2024-11-08 → 2025-10-31 A (+357d) |  | 0% → 100% | 0d → none | 44FS+5d → 44 | baseline start none → 2024-11-11; baseline finish none → 2024-11-15 |
| 67 | Rohrleitungen HLS | 2024-11-11 → 2025-11-10 A (+364d) | 2024-11-22 → 2025-11-21 A (+364d) |  | 0% → 100% | 0d → none | 66 → 66, 45 | baseline start none → 2024-11-18; baseline finish none → 2024-11-29 |
| 68 | Leitungen Boden | 2024-11-18 → 2025-11-17 A (+364d) | 2024-11-22 → 2025-11-21 A (+364d) |  | 0% → 100% | 0d → none |  | resources Elektro → Elektro - Fa. Elektro Blitz; baseline start none → 2024-11-25; baseline finish none → 2024-11-29 |
| 69 | Hohlboden | 2024-11-25 → 2025-11-24 A (+364d) | 2024-11-29 → 2025-11-28 A (+364d) |  | 0% → 100% | 0d → none |  | baseline start none → 2024-12-02; baseline finish none → 2024-12-06 |
| 70 | Estrich | 2024-12-02 → 2025-12-01 A (+364d) | 2024-12-03 → 2025-12-02 A (+364d) |  | 0% → 100% | 0d → none |  | baseline start none → 2024-12-09; baseline finish none → 2024-12-10 |
| 71 | Estrich Trocknung | 2024-12-04 → 2025-12-03 A (+364d) | 2024-12-13 → 2025-12-12 A (+364d) |  | 0% → 100% | 0d → none |  | baseline start none → 2024-12-11; baseline finish none → 2024-12-20 |

| ID | Task | Start | Finish | Duration | Complete | Total float | Other |
| --- | --- | --- | --- | --- | --- | --- | --- |
| 72 | Eckwand + 1. Seite | 2024-12-30 → 2025-12-29 A (+364d) | 2025-01-03 → 2026-01-02 A (+364d) |  | 0% → 100% | 0d → none | baseline start none → 2025-01-06; baseline finish none → 2025-01-10 |
| 73 | Leitung Wand | 2025-01-06 → 2026-01-05 A (+364d) | 2025-01-10 → 2026-01-09 A (+364d) |  | 0% → 100% | 0d → none | resources Elektro → Elektro - Fa. Elektro Blitz; baseline start none → 2025-01-13; baseline finish none → 2025-01-17 |
| 74 | 2. Seite + Q3 | 2025-01-13 → 2026-01-12 A (+364d) | 2025-01-17 → 2026-01-16 (+364d) |  | 0% → 80% | 0d → none | baseline start none → 2025-01-20; baseline finish none → 2025-01-24 |
| 75 | 1. Anstrich | 2025-01-20 → 2026-01-19 (+364d) | 2025-01-24 → 2026-01-23 (+364d) |  |  | 0d → none | baseline start none → 2025-01-27; baseline finish none → 2025-01-31 |
| 76 | Systemtrennwände | 2025-01-27 → 2026-01-26 (+364d) | 2025-02-07 → 2026-02-06 (+364d) |  |  | 0d → none | baseline start none → 2025-02-03; baseline finish none → 2025-02-14 |
| 77 | Bodenbelag | 2025-02-10 → 2026-02-09 (+364d) | 2025-02-14 → 2026-02-13 (+364d) |  |  | 0d → none | baseline start none → 2025-02-17; baseline finish none → 2025-02-21 |
| 78 | Bodentanks | 2025-02-17 → 2026-02-16 (+364d) | 2025-02-21 → 2026-02-20 (+364d) |  |  | 0d → none | baseline start none → 2025-02-24; baseline finish none → 2025-02-28 |
| 79 | Türen | 2025-02-17 → 2026-02-16 (+364d) | 2025-02-21 → 2026-02-20 (+364d) |  |  | 0d → none | baseline start none → 2025-02-24; baseline finish none → 2025-02-28 |
| 80 | Heizkörper | 2025-02-24 → 2026-02-23 (+364d) | 2025-02-28 → 2026-02-27 (+364d) |  |  | 0d → none | baseline start none → 2025-03-03; baseline finish none → 2025-03-07 |
| 81 | Feininstallation HLS | 2025-02-24 → 2026-02-23 (+364d) | 2025-03-07 → 2026-03-06 (+364d) |  |  | 0d → none | baseline start none → 2025-03-03; baseline finish none → 2025-03-14 |
| 82 | Schließzylinder | 2025-03-10 → 2026-03-09 (+364d) | 2025-03-10 → 2026-03-09 (+364d) |  |  | 0d → none | baseline start none → 2025-03-17; baseline finish none → 2025-03-17 |
| 83 | Schalter + Lampen | 2025-03-10 → 2026-03-09 (+364d) | 2025-03-14 → 2026-03-13 (+364d) |  |  | 0d → none | resources Elektro → Elektro - Fa. Elektro Blitz; baseline start none → 2025-03-17; baseline finish none → 2025-03-21 |
| 84 | 2. Anstrich | 2025-03-17 → 2026-03-16 (+364d) | 2025-03-21 → 2026-03-20 (+364d) |  |  | 0d → none | baseline start none → 2025-03-24; baseline finish none → 2025-03-28 |
| 85 | WC-Gegenstände | 2025-03-24 → 2026-03-23 (+364d) | 2025-03-28 → 2026-03-27 (+364d) |  |  | 0d → none | resources Sanitär → Sanitär - Fa. Rohr Frei; baseline start none → 2025-03-31; baseline finish none → 2025-04-04 |
| 86 | Endreinigung | 2025-03-31 → 2026-03-30 (+364d) | 2025-04-04 → 2026-04-03 (+364d) |  |  | 0d → none | resources Reinigung → Reinigung - Fa. Gebäudereinigung Blitzblank; baseline start none → 2025-04-07; baseline finish none → 2025-04-11 |
| 87 | Ausbau fertig | 2025-04-04 → 2026-04-06 (+367d) | 2025-04-04 → 2026-04-06 (+367d) |  |  | 0d → none | baseline start none → 2025-04-14; baseline finish none → 2025-04-14 |
| 109 | **Mängelbeseitigung** | 2025-05-26 → 2026-05-25 (+364d) | 2025-07-11 → 2026-05-25 (+318d) | 35d → 1d |  | 0d → none | baseline start none → 2025-06-02; baseline finish none → 2025-07-21 |
| 110 | Mängelaufnahme | 2025-05-26 → 2026-05-25 (+364d) | 2025-05-30 → 2026-05-29 (+364d) |  |  | 0d → none | resources none → Mängelmanagement; baseline start none → 2025-06-02; baseline finish none → 2025-06-06 |
| 111 | Dokumentation | 2025-06-02 → 2026-06-01 (+364d) | 2025-06-06 → 2026-06-05 (+364d) |  |  | 0d → none | resources none → Mängelmanagement; baseline start none → 2025-06-09; baseline finish none → 2025-06-13 |
| 112 | Mängelabarbeitung | 2025-06-09 → 2026-06-08 (+364d) | 2025-07-04 → 2026-07-03 (+364d) |  |  | 0d → none | resources none → Mängelmanagement; baseline start none → 2025-06-16; baseline finish none → 2025-07-11 |
| 113 | Nachkontrolle | 2025-07-07 → 2026-07-06 (+364d) | 2025-07-11 → 2026-07-10 (+364d) |  |  | 0d → none | resources none → Mängelmanagement; baseline start none → 2025-07-14; baseline finish none → 2025-07-18 |
| 114 | Mängelfrei | 2025-07-11 → 2026-07-13 (+367d) | 2025-07-11 → 2026-07-13 (+367d) |  |  | 0d → none | baseline start none → 2025-07-21; baseline finish none → 2025-07-21 |
| 115 | **Inbetriebnahme** | 2025-04-21 → 2026-04-20 (+364d) | 2025-08-22 → 2026-04-20 (+241d) | 90d → 1d |  | 0d → none | baseline start none → 2025-04-28; baseline finish none → 2025-07-28 |
| 116 | Inbetriebnahme TGA | 2025-04-21 → 2026-04-20 (+364d) | 2025-05-16 → 2026-05-15 (+364d) |  |  | 0d → none | baseline start none → 2025-04-28; baseline finish none → 2025-05-23 |
| 117 | Übergabe an Bauherr | 2025-07-18 → 2026-07-20 (+367d) | 2025-07-18 → 2026-07-20 (+367d) |  |  | 0d → none | baseline start none → 2025-07-28; baseline finish none → 2025-07-28 |
